# Example Schedule 2

Schedule from MS Project, 2015-01-05 to 2015-08-06.
McCann Worldgroup

## Calendars

- Standard: Mon-Fri 08:00-12:00, 13:00-17:00; Sat-Sun off.

## Resources

| Resource |
| --- |
| IA |
| Project Manager |
| ALL |
| Client |
| Creative |
| Design |
| QA |
| Analytics |
| SEO |
| Dev |
| FE Dev |
| Dev 1 |
| Dev 2 |
| Dev 3 |
| Dev 4 |
| Dev 5 |
| Web Dev |
| Asset Mgr |
| Team |
| Infrastructure |
| Copy |
| Proof |
| Legal |
| Jacob |
| Sandy |
| ALex |
| Tim |
| Paul |
| Charlie |
| Content Author |

## Schedule

| ID | WBS | Task | Type | Duration | Start | Finish | Predecessors | Total slack | Resources | Work |
| --- | --- | --- | --- | --- | --- | --- | --- | --- | --- | --- |
| 1 | 1 | **Jetzen** |  | 154d? | 2015-01-05 | 2015-08-06 |  | 0d |  | 3816h |
| 2 | 1.1 | Gap Analysis Presentation | milestone, manual | 0d | 2015-01-05 | 2015-01-05 |  |  | IA |  |
| 3 | 1.2 | Business Requirements Finalized | milestone, manual | 0d | 2015-01-26 | 2015-01-26 |  |  | IA; Project Manager |  |
| 4 | 1.3 | Statement of Work Approved | milestone, manual | 0d | 2015-01-30 | 2015-01-30 |  |  |  |  |
| 5 | 1.4 | **Sitemap** |  | 9d | 2015-02-02 | 2015-02-12 |  | 0d |  | 72h |
| 6 | 1.4.1 | Sitemap Developed by IA | manual | 5d | 2015-02-02 | 2015-02-06 |  |  | IA | 40h |
| 7 | 1.4.2 | Team Review of Sitemap | manual | 1d | 2015-02-09 | 2015-02-09 | 6 |  | ALL | 8h |
| 8 | 1.4.3 | IA Incorporates Changes | manual | 2d | 2015-02-10 | 2015-02-11 | 7 |  | IA | 16h |
| 9 | 1.4.4 | Final Sitemap Review and Approval of Sitemap | manual | 1d | 2015-02-12 | 2015-02-12 | 8 |  | Client | 8h |
| 10 | 1.5 | **Group 1 - Navigation and Homepage** |  | 25d | 2015-02-13 | 2015-03-19 |  | 0d |  | 200h |
| 11 | 1.5.1 | Wireframe Development | manual | 5d | 2015-02-13 | 2015-02-19 | 9 |  | IA | 40h |
| 12 | 1.5.2 | Wireframe Presentation | manual | 1d | 2015-02-20 | 2015-02-20 | 11 |  | IA | 8h |
| 13 | 1.5.3 | Revisions Distributed to Team | manual | 2d | 2015-02-23 | 2015-02-24 | 12 |  | IA | 16h |
| 14 | 1.5.4 | Client approval | manual | 1d | 2015-02-25 | 2015-02-25 | 13 |  | Client | 8h |
| 15 | 1.5.5 | Comp Development | manual | 10d | 2015-02-26 | 2015-03-11 | 14 |  | Design | 80h |
| 16 | 1.5.6 | Style Guide Development | manual | 5d | 2015-03-12 | 2015-03-18 | 15 |  | Creative | 40h |
| 17 | 1.5.7 | Styleguide Presentation | manual | 1d | 2015-03-19 | 2015-03-19 | 16 |  | Creative | 8h |
| 18 | 1.6 | **Group 2 - About Jetzen and Owner Resources** |  | 26d | 2015-02-26 | 2015-04-02 |  | 0d |  | 200h |
| 19 | 1.6.1 | Wireframe Development | manual | 5d | 2015-02-26 | 2015-03-04 | 14 |  | IA | 40h |
| 20 | 1.6.2 | Wireframe Presentation | manual | 1d | 2015-03-05 | 2015-03-05 | 19 |  | IA | 8h |
| 21 | 1.6.3 | Revisions Distributed to Team | manual | 2d | 2015-03-06 | 2015-03-09 | 20 |  | IA | 16h |
| 22 | 1.6.4 | Client approval | manual | 1d | 2015-03-10 | 2015-03-10 | 21 |  | Client | 8h |
| 23 | 1.6.5 | Comp Development | manual | 10d | 2015-03-12 | 2015-03-25 | 15 |  | Design | 80h |
| 24 | 1.6.6 | Style Guide Development | manual | 5d | 2015-03-26 | 2015-04-01 | 23 |  | Creative | 40h |
| 25 | 1.6.7 | Styleguide Presentation | manual | 1d | 2015-04-02 | 2015-04-02 | 24 |  | Creative | 8h |

| ID | WBS | Task | Type | Duration | Start | Finish | Predecessors | Total slack | Resources | Work |
| --- | --- | --- | --- | --- | --- | --- | --- | --- | --- | --- |
| 26 | 1.7 | **Group 3 - Choosing a Spaceship** |  | 27d | 2015-03-11 | 2015-04-16 |  | 0d |  | 192h |
| 27 | 1.7.1 | Wireframe Development | manual | 5d | 2015-03-11 | 2015-03-17 | 22 |  | IA | 40h |
| 28 | 1.7.2 | Wireframe Presentation | manual | 1d | 2015-03-18 | 2015-03-18 | 27 |  | IA | 8h |
| 29 | 1.7.3 | Revisions Distributed to Team | manual | 2d | 2015-03-19 | 2015-03-20 | 28 |  | IA | 16h |
| 30 | 1.7.4 | Client approval | manual | 1d | 2015-03-23 | 2015-03-23 | 29 |  | Client | 8h |
| 31 | 1.7.5 | **Comp Development** |  | 10d | 2015-03-26 | 2015-04-09 |  | 0d |  | 72h |
| 32 | 1.7.5.1 | Initial Creative Development | manual | 3d | 2015-03-26 | 2015-03-30 | 23 |  | Design | 24h |
| 33 | 1.7.5.2 | Internal Review | manual | 1d | 2015-03-31 | 2015-03-31 | 32 |  |  |  |
| 34 | 1.7.5.3 | Comps are updated | milestone, manual | 0d | 2015-04-01 | 2015-04-01 | 33 |  | Design |  |
| 35 | 1.7.5.4 | Client Review | manual | 1d | 2015-04-01 | 2015-04-01 | 34 |  | Client | 8h |
| 36 | 1.7.5.5 | Copy development | manual | 1d | 2015-04-02 | 2015-04-02 | 35 |  | Copy | 8h |
| 37 | 1.7.5.6 | Comps are updated | manual | 1d | 2015-04-03 | 2015-04-03 | 36 |  | Design | 8h |
| 38 | 1.7.5.7 | Proofreading Review | manual | 1d | 2015-04-06 | 2015-04-06 | 37 |  | Proof | 8h |
| 39 | 1.7.5.8 | Final Client Review | manual | 1d | 2015-04-07 | 2015-04-07 | 38 |  | Client | 8h |
| 40 | 1.7.5.9 | Legal Review | manual | 1d | 2015-04-08 | 2015-04-08 | 39 |  | Legal | 8h |
| 41 | 1.7.5.10 | Delivery | milestone, manual | 0d | 2015-04-09 | 2015-04-09 | 40 |  | Design |  |
| 42 | 1.7.6 | Style Guide Development | manual | 5d | 2015-04-09 | 2015-04-15 |  |  | Creative | 40h |
| 43 | 1.7.7 | Styleguide Presentation | manual | 1d | 2015-04-16 | 2015-04-16 | 42 |  | Creative | 8h |
| 44 | 1.8 | **Group 4 - Jetzen News** |  | 28d | 2015-03-24 | 2015-04-30 |  | 0d |  | 200h |
| 45 | 1.8.1 | Wireframe Development | manual | 5d | 2015-03-24 | 2015-03-30 | 30 |  | IA | 40h |
| 46 | 1.8.2 | Wireframe Presentation | manual | 1d | 2015-03-31 | 2015-03-31 | 45 |  | IA | 8h |
| 47 | 1.8.3 | Revisions Distributed to Team | manual | 2d | 2015-04-01 | 2015-04-02 | 46 |  | IA | 16h |
| 48 | 1.8.4 | Client approval | manual | 1d | 2015-04-03 | 2015-04-03 | 47 |  | Client | 8h |
| 49 | 1.8.5 | Comp Development | manual | 10d | 2015-04-09 | 2015-04-22 | 31 |  | Design | 80h |
| 50 | 1.8.6 | Style Guide Development | manual | 5d | 2015-04-23 | 2015-04-29 | 49 |  | Creative | 40h |
| 51 | 1.8.7 | Styleguide Presentation | manual | 1d | 2015-04-30 | 2015-04-30 | 50 |  | Creative | 8h |

| ID | WBS | Task | Type | Duration | Start | Finish | Predecessors | Total slack | Resources | Work |
| --- | --- | --- | --- | --- | --- | --- | --- | --- | --- | --- |
| 52 | 1.9 | **Group 5 - Help and Tools** |  | 29d | 2015-04-06 | 2015-05-14 |  | 0d |  | 200h |
| 53 | 1.9.1 | Wireframe Development | manual | 5d | 2015-04-06 | 2015-04-10 | 48 |  | IA | 40h |
| 54 | 1.9.2 | Wireframe Presentation | manual | 1d | 2015-04-13 | 2015-04-13 | 53 |  | IA | 8h |
| 55 | 1.9.3 | Revisions Distributed to Team | manual | 2d | 2015-04-14 | 2015-04-15 | 54 |  | IA | 16h |
| 56 | 1.9.4 | Client approval | manual | 1d | 2015-04-16 | 2015-04-16 | 55 |  | Client | 8h |
| 57 | 1.9.5 | Comp Development | manual | 10d | 2015-04-23 | 2015-05-06 | 49 |  | Design | 80h |
| 58 | 1.9.6 | Style Guide Development | manual | 5d | 2015-05-07 | 2015-05-13 | 57 |  | Creative | 40h |
| 59 | 1.9.7 | Styleguide Presentation | manual | 1d | 2015-05-14 | 2015-05-14 | 58 |  | Creative | 8h |
| 60 | 1.10 | Scope Freeze |  | 1d | 2015-05-15 | 2015-05-15 | 59 | 59d |  |  |
| 61 | 1.11 | <New Task> | manual | 1d? | 2015-01-05 | 2015-01-05 |  |  |  |  |
| 62 | 1.12 | **Technical Prep** |  | 13d | 2015-05-15 | 2015-06-02 |  | 0d |  | 264h |
| 63 | 1.12.1 | Prepare Testing Strategy and Cases | manual | 10d | 2015-05-15 | 2015-05-28 | 59 |  | QA | 80h |
| 64 | 1.12.2 | Review of Test Strategy and Cases | manual | 3d | 2015-05-29 | 2015-06-02 | 63 |  | Project Manager | 24h |
| 65 | 1.12.3 | Analytics Analysis | manual | 10d | 2015-05-15 | 2015-05-28 | 59 |  | Analytics | 80h |
| 66 | 1.12.4 | SEO Analysis | manual | 10d | 2015-05-15 | 2015-05-28 | 59 |  | SEO | 80h |
| 67 | 1.13 | **Development** |  | 82d | 2015-03-20 | 2015-07-13 |  | 0d |  | 1864h |
| 68 | 1.13.1 | CSS | manual | 50d | 2015-03-20 | 2015-05-28 | 17 |  | Jacob | 400h |
| 69 | 1.13.2 | HTML Framework | manual | 60d | 2015-03-20 | 2015-06-11 | 17 |  | Sandy | 480h |
| 70 | 1.13.3 | Search | manual | 4d | 2015-03-20 | 2015-03-25 | 17 |  | Tim | 32h |
| 71 | 1.13.4 | News Stories | manual | 25d | 2015-05-01 | 2015-06-04 | 51 |  | Paul | 200h |
| 72 | 1.13.5 | Video Gallery | manual | 14d | 2015-04-17 | 2015-05-06 | 43 |  | Tim | 112h |
| 73 | 1.13.6 | Configurator | manual | 42d | 2015-05-15 | 2015-07-13 | 59 |  | Charlie | 336h |
| 74 | 1.13.7 | Trip Planner | manual | 26d | 2015-06-05 | 2015-07-10 | 71 |  | Paul | 208h |
| 75 | 1.13.8 | Contact Us Form | manual | 12d | 2015-05-15 | 2015-06-01 | 59 |  | Tim | 96h |

| ID | WBS | Task | Type | Duration | Start | Finish | Predecessors | Total slack | Resources | Work |
| --- | --- | --- | --- | --- | --- | --- | --- | --- | --- | --- |
| 76 | 1.14 | **Asset Delivery from CAOR** |  | 16d | 2015-06-01 | 2015-06-22 |  | 0d |  | 24h |
| 77 | 1.14.1 | Group 1 | manual | 1d | 2015-06-01 | 2015-06-01 |  |  | Creative | 8h |
| 78 | 1.14.2 | Group 2 | manual | 1d | 2015-06-08 | 2015-06-08 |  |  | Creative | 8h |
| 79 | 1.14.3 | Group 3 | manual | 1d | 2015-06-22 | 2015-06-22 |  |  | Creative | 8h |
| 80 | 1.15 | **Internal AQR** |  | 17d | 2015-06-02 | 2015-06-24 |  | 0d |  | 48h |
| 81 | 1.15.1 | Group 1 | manual | 2d | 2015-06-02 | 2015-06-03 | 77 |  | Asset Mgr | 16h |
| 82 | 1.15.2 | Group 2 | manual | 2d | 2015-06-09 | 2015-06-10 | 78 |  | Asset Mgr | 16h |
| 83 | 1.15.3 | Group 3 | manual | 2d | 2015-06-23 | 2015-06-24 | 79 |  | Asset Mgr | 16h |
| 84 | 1.16 | **AQR Fixes** |  | 16d | 2015-06-04 | 2015-06-25 |  | 0d |  | 24h |
| 85 | 1.16.1 | Group 1 | manual | 1d | 2015-06-04 | 2015-06-04 | 81 |  | Creative | 8h |
| 86 | 1.16.2 | Group 2 | manual | 1d | 2015-06-11 | 2015-06-11 | 82 |  | Creative | 8h |
| 87 | 1.16.3 | Group 3 | manual | 1d | 2015-06-25 | 2015-06-25 | 83 |  | Creative | 8h |
| 88 | 1.17 | **Content Input** |  | 20d | 2015-06-05 | 2015-07-02 |  | 0d |  | 120h |
| 89 | 1.17.1 | Group 1 | manual | 5d | 2015-06-05 | 2015-06-11 | 85 |  | Content Author | 40h |
| 90 | 1.17.2 | Group 2 | manual | 5d | 2015-06-12 | 2015-06-18 | 86 |  | Content Author | 40h |
| 91 | 1.17.3 | Group 3 | manual | 5d | 2015-06-26 | 2015-07-02 | 87 |  | Content Author | 40h |
| 92 | 1.18 | **Internal QA** |  | 17d | 2015-06-12 | 2015-07-06 |  | 0d |  | 48h |
| 93 | 1.18.1 | Group 1 | manual | 2d | 2015-06-12 | 2015-06-15 | 89 |  | QA | 16h |
| 94 | 1.18.2 | Group 2 | manual | 2d | 2015-06-19 | 2015-06-22 | 90 |  | QA | 16h |
| 95 | 1.18.3 | Group 3 | manual | 2d | 2015-07-03 | 2015-07-06 | 91 |  | QA | 16h |
| 96 | 1.19 | **SIT** |  | 84d | 2015-03-26 | 2015-07-21 |  | 0d |  | 152h |
| 97 | 1.19.1 | **Search** |  | 5d | 2015-03-26 | 2015-04-01 |  | 0d |  |  |
| 98 | 1.19.1.1 | Code deployment to Pre Env | manual | 1d | 2015-03-26 | 2015-03-26 | 70 |  |  |  |
| 99 | 1.19.1.2 | Internal Review | manual | 2d | 2015-03-27 | 2015-03-30 | 98 |  |  |  |
| 100 | 1.19.1.3 | Code Fixes | manual | 2d | 2015-03-31 | 2015-04-01 | 99 |  |  |  |

| ID | WBS | Task | Type | Duration | Start | Finish | Predecessors | Total slack | Resources | Work |
| --- | --- | --- | --- | --- | --- | --- | --- | --- | --- | --- |
| 101 | 1.19.2 | **Video Gallery** |  | 5d | 2015-05-07 | 2015-05-13 |  | 0d |  | 40h |
| 102 | 1.19.2.1 | Code deployment to Pre Env | manual | 1d | 2015-05-07 | 2015-05-07 | 72 |  | Tim | 8h |
| 103 | 1.19.2.2 | Internal Review | manual | 2d | 2015-05-08 | 2015-05-11 | 102 |  | QA | 16h |
| 104 | 1.19.2.3 | Code Fixes | manual | 2d | 2015-05-12 | 2015-05-13 | 103 |  | Tim | 16h |
| 105 | 1.19.3 | **Contact Us Form** |  | 5d | 2015-06-04 | 2015-06-10 |  | 0d |  | 40h |
| 106 | 1.19.3.1 | Code deployment to Pre Env | manual | 1d | 2015-06-04 | 2015-06-04 | 75FS+2d |  | Tim | 8h |
| 107 | 1.19.3.2 | Internal Review | manual | 2d | 2015-06-05 | 2015-06-08 | 106 |  | QA | 16h |
| 108 | 1.19.3.3 | Code Fixes | manual | 2d | 2015-06-09 | 2015-06-10 | 107 |  | Tim | 16h |
| 109 | 1.19.4 | **News Stories** |  | 5d | 2015-06-11 | 2015-06-17 |  | 0d |  | 40h |
| 110 | 1.19.4.1 | Code deployment to Pre Env | manual | 1d | 2015-06-11 | 2015-06-11 | 71FS+4d |  | Paul | 8h |
| 111 | 1.19.4.2 | Internal Review | manual | 2d | 2015-06-12 | 2015-06-15 | 110 |  | QA | 16h |
| 112 | 1.19.4.3 | Code Fixes | manual | 2d | 2015-06-16 | 2015-06-17 | 111 |  | Paul | 16h |
| 113 | 1.19.5 | **Trip Planner** |  | 4d | 2015-07-16 | 2015-07-21 |  | 0d |  |  |
| 114 | 1.19.5.1 | Code deployment to Pre Env | milestone, manual | 0d | 2015-07-16 | 2015-07-16 | 74FS+3d |  |  |  |
| 115 | 1.19.5.2 | Internal Review | manual | 2d | 2015-07-16 | 2015-07-17 | 114 |  |  |  |
| 116 | 1.19.5.3 | Code Fixes | manual | 2d | 2015-07-20 | 2015-07-21 | 115 |  |  |  |
| 117 | 1.19.6 | **Configurator** |  | 4d | 2015-07-16 | 2015-07-21 |  | 0d |  | 32h |
| 118 | 1.19.6.1 | Code deployment to Pre Env | manual | 1d | 2015-07-16 | 2015-07-16 | 73FS+2d |  | Charlie | 8h |
| 119 | 1.19.6.2 | Internal Review | manual | 1d | 2015-07-17 | 2015-07-17 | 118 |  | QA | 8h |
| 120 | 1.19.6.3 | Code Fixes | manual | 2d | 2015-07-20 | 2015-07-21 | 119 |  | Charlie | 16h |
| 121 | 1.20 | **UAT** |  | 50d | 2015-05-29 | 2015-08-06 |  | 0d |  | 200h |
| 122 | 1.20.1 | Search Review | manual | 3d | 2015-05-29 | 2015-06-02 |  |  | Team | 24h |
| 123 | 1.20.2 | Video Gallery Review | manual | 3d | 2015-05-29 | 2015-06-02 |  |  | Team | 24h |
| 124 | 1.20.3 | Contact Us Review | manual | 3d | 2015-06-11 | 2015-06-15 | 108 |  | Team | 24h |
| 125 | 1.20.4 | News Stories Review | manual | 3d | 2015-06-18 | 2015-06-22 | 112 |  | Team | 24h |
| 126 | 1.20.5 | Trip Planner Review | manual | 3d | 2015-07-22 | 2015-07-24 | 116 |  | Team | 24h |
| 127 | 1.20.6 | Creative Review | manual | 3d | 2015-07-22 | 2015-07-24 | 120 |  | Creative | 24h |
| 128 | 1.20.7 | Fixes | manual | 3d | 2015-07-29 | 2015-07-31 | 127 |  | Dev | 24h |
| 129 | 1.20.8 | Final team review | manual | 3d | 2015-08-03 | 2015-08-05 | 128 |  | Team | 24h |
| 130 | 1.20.9 | Fixes | manual | 1d | 2015-08-06 | 2015-08-06 | 129 |  | Dev | 8h |
| 131 | 1.21 | Cutover | manual | 1d | 2015-08-06 | 2015-08-06 | 130 |  | Infrastructure | 8h |
